# 2016 winter shut down target hall schedule

Schedule from MS Project, 2016-02-11 to 2016-05-16, A marks actual dates.

## Calendars

- Standard: Mon-Fri 08:00-12:00, 13:00-17:00; Sat-Sun off.

## Resources

| Resource |
| --- |
| Wang.D |
| Cave.T |
| Fisher.C |
| McDonald.D |
| RPG |
| Jackson.D |
| Mjos.A |
| Minor.G |
| Paley.B |
| Vacuum Group |
| Plant Group |
| Target Group |

## Schedule

| ID | WBS | Task | Duration | Start | Finish | Predecessors | Complete | Total slack | Free slack | Constraint | Resources | Work | Actual work |
| --- | --- | --- | --- | --- | --- | --- | --- | --- | --- | --- | --- | --- | --- |
| 1 | 1 | **TM3 Service Chase and Containment box Field Check** | 2d | 2016-02-15 08:00 A | 2016-02-16 17:00 A |  | 100% |  |  |  |  | 48h | 48h |
| 2 | 1.1 | TM3 Service Chase and Containment box Field Check | 2d | 2016-02-15 08:00 A | 2016-02-16 17:00 A |  | 100% |  |  | start no earlier than 2016-02-15 08:00 | Target Group; RPG; Wang.D | 48h | 48h |
| 3 | 2 | **TARGET HALL WATER SYSTEM UPGRADE** | 5d | 2016-02-17 08:00 A | 2016-02-23 17:00 A |  | 100% |  |  |  |  | 40h | 40h |
| 4 | 2.1 | Shielding Blocks Move for Work Area Accessing | 1d | 2016-02-17 08:00 A | 2016-02-17 17:00 A |  | 100% |  |  | finish no earlier than 2016-02-17 17:00 | Wang.D; McDonald.D | 16h | 16h |
| 5 | 2.2 | Water Sytem Upgrade and Test | 3d | 2016-02-19 08:00 A | 2016-02-23 17:00 A | 4 | 100% |  |  | start no earlier than 2016-02-19 08:00 | Wang.D; Mjos.A; Plant Group | 24h | 24h |
| 6 | 3 | **Shut Down Leak Check - Target Stations and Modules** | 4d | 2016-02-24 08:00 A | 2016-02-29 17:00 A |  | 100% |  |  |  |  | 64h | 64h |
| 7 | 3.1 | Module Disconnection-TM2/ITW | 1d | 2016-02-26 08:00 A | 2016-02-26 17:00 A | 4 | 100% |  |  | start no earlier than 2016-02-26 08:00 | Wang.D; McDonald.D | 16h | 16h |
| 8 | 3.2 | ITW and TM2 Vacuum Leak Check | 1d | 2016-02-29 08:00 A | 2016-02-29 17:00 A | 7 | 100% |  |  | start no earlier than 2016-02-29 08:00 | Wang.D; McDonald.D | 16h | 16h |
| 9 | 3.3 | Shielding Blocks Move- ITE to Storage Area | 0.5d | 2016-02-24 08:00 A | 2016-02-24 12:00 A |  | 100% |  |  | start no earlier than 2016-02-24 08:00 | Wang.D; McDonald.D | 8h | 8h |
| 10 | 3.4 | Module Disconnection-TM4-ITE | 0.5d | 2016-02-24 13:00 A | 2016-02-24 17:00 A | 9 | 100% |  |  | start no earlier than 2016-02-16 08:00 | Wang.D; McDonald.D | 8h | 8h |
| 11 | 3.5 | ITE and TM4 Vacuum leak Check | 1d | 2016-02-25 08:00 A | 2016-02-25 17:00 A | 10 | 100% |  |  | start no earlier than 2016-02-17 08:00 | McDonald.D; Wang.D | 16h | 16h |
| 12 | 4 | **ISAC Spent targets Shipment** | 6d | 2016-02-11 08:00 A | 2016-02-18 17:00 A |  | 100% |  |  |  |  | 40h | 40h |
| 13 | 4.1 | F308s Move- Ante Room to Target Hall | 0.5d | 2016-02-11 08:00 A | 2016-02-11 12:00 A |  | 100% |  |  | start no earlier than 2016-02-11 08:00 | Cave.T; Wang.D | 8h | 8h |
| 14 | 4.2 | Working area Set up | 0.5d | 2016-02-11 13:00 A | 2016-02-11 17:00 A | 13 | 100% |  |  | start no earlier than 2016-02-11 08:00 | Cave.T; Wang.D | 8h | 8h |
| 15 | 4.3 | Speant Targets Transfer- Mini Storage to F308s | 0.5d | 2016-02-18 08:00 A | 2016-02-18 12:00 A | 14 | 100% |  |  | start no earlier than 2016-02-18 08:00 | Cave.T; RPG; Wang.D | 12h | 12h |
| 16 | 4.4 | F308s Move- Target Hall to Ante Room | 0.5d | 2016-02-18 13:00 A | 2016-02-18 17:00 A | 15 | 100% |  |  | start no earlier than 2016-02-18 08:00 | Wang.D; McDonald.D; Cave.T | 12h | 12h |
| 17 | 5 | ITH MP1 Replacement | 1d | 2016-03-10 08:00 A | 2016-03-10 17:00 A |  | 100% |  |  | start no earlier than 2016-03-10 08:00 | Vacuum Group; Wang.D | 16h | 16h |
| 18 | 6 | **TM1 with New Lp Ucx target to ITW** | 14.75d | 2016-03-16 08:00 | 2016-04-05 15:00 |  |  | 29.25d |  |  |  | 154.4h |  |
| 19 | 6.1 | Module Move -TM2- ITW to SHC | 0.5d | 2016-03-16 08:00 | 2016-03-16 12:00 |  |  | 38.2d | 0d | start no earlier than 2016-03-16 08:00 | Cave.T; Wang.D; McDonald.D | 12h |  |
| 20 | 6.2 | Electrical Check Before and After / Target Removal | 0.5d | 2016-03-16 13:00 | 2016-03-16 17:00 | 19 |  | 38.2d | 0d | start no earlier than 2016-03-14 08:00 | Cave.T; Wang.D; Fisher.C | 12h |  |
| 21 | 6.3 | Module Move-TM2- SHC to TCS | 0.5d | 2016-03-17 08:00 | 2016-03-17 12:00 | 20 |  | 38.2d | 0d | start no earlier than 2016-03-15 08:00 | Cave.T; Wang.D | 8h |  |
| 22 | 6.4 | Module Connection-TM2-TCS/ Start of Pumps | 0.5d | 2016-03-17 13:00 | 2016-03-17 17:00 | 21 |  | 38.2d | 0d | finish no earlier than 2016-03-15 17:00 | McDonald.D; Wang.D | 8h |  |
| 23 | 6.5 | TM2 water Lines Helium Pressur Leak Check | 0.5d | 2016-03-18 08:00 | 2016-03-18 12:00 | 22 |  | 38.2d | 0d | start no earlier than 2016-03-16 08:00 | McDonald.D; Wang.D | 8h |  |
| 24 | 6.6 | Target inspection | 0.5d | 2016-03-18 13:00 | 2016-03-18 17:00 | 23 |  | 38.2d | 0d | start no earlier than 2016-03-16 08:00 | Fisher.C; Mjos.A | 8h |  |
| 25 | 6.7 | Spent Target Move | 0.5d | 2016-03-22 08:00 | 2016-03-22 12:00 | 24 |  | 7.1d | 0d | start no earlier than 2016-03-22 08:00 | Cave.T; Fisher.C; Wang.D | 12h |  |
| 26 | 6.8 | Module Move-TM2- TCS to SHC | 0.5d | 2016-03-22 13:00 | 2016-03-22 17:00 | 25 |  | 7.1d | 0d | start no earlier than 2016-03-17 08:00 | Cave.T; Wang.D | 8h |  |
| 27 | 6.9 | Contaiment Box Moved out | 0.5d | 2016-03-23 08:00 | 2016-03-23 12:00 | 26 |  | 7.1d | 0d | start no earlier than 2016-03-18 08:00 | Fisher.C | 4h |  |
| 28 | 6.10 | Leak Check - TM2 -SHC | 0.5d | 2016-03-23 13:00 | 2016-03-23 17:00 | 27 |  | 7.1d | 0d | finish no earlier than 2016-03-21 17:00 | Fisher.C; Wang.D | 8h |  |
| 29 | 6.11 | Containment Box Re-installed | 0.1d | 2016-03-24 08:00 | 2016-03-24 08:48 | 28 |  | 7.1d | 0d | start no earlier than 2016-03-22 08:00 | Fisher.C | 0.8h |  |
| 30 | 6.12 | Module Move-TM2 -SHC to Silo | 0.25d | 2016-03-24 08:48 | 2016-03-24 10:48 | 29 |  | 13.25d | 0.5d | start no earlier than 2016-03-24 08:00 | Cave.T; Wang.D | 4h |  |
| 31 | 6.13 | Module Move -TM1- Silo to TCS | 0.15d | 2016-03-24 15:48 | 2016-03-24 17:00 | 30 |  | 36.75d | 0d | finish no earlier than 2016-03-24 17:00 | Cave.T; Wang.D | 2.4h |  |
| 32 | 6.14 | Module connection -TM1-TCS /Start of Pumps | 0.25d | 2016-03-25 08:00 | 2016-03-25 10:00 | 31 |  | 12.75d |  | start no earlier than 2016-03-24 08:00 | Wang.D | 2h |  |
| 33 | 6.15 | Module Check-TM1 -TCS-Electrical, Vacuum | 2d | 2016-03-29 08:00 | 2016-03-30 17:00 |  |  | 33d |  | start no earlier than 2016-03-29 08:00 | Cave.T; Wang.D | 32h |  |
| 34 | 6.16 | NewLp Ucx inert into SHC/TM1 Move TCS to SHC | 0.2d | 2016-04-01 08:00 | 2016-04-01 09:36 | 29 |  | 1.2d | 0d | start no earlier than 2016-04-01 08:00 | Fisher.C; Target Group | 3.2h |  |
| 35 | 6.17 | New Lp UCx Installation | 0.2d | 2016-04-01 09:36 | 2016-04-01 11:12 | 34 |  | 1.2d | 0d | start no earlier than 2016-03-18 08:00 | Fisher.C | 1.6h |  |
| 36 | 6.18 | TM1 with New Target Leak and Electrical Check- SHC | 0.1d | 2016-04-01 11:12 | 2016-04-01 12:00 | 35 |  | 1.2d | 0d | start no earlier than 2016-03-18 08:00 | Fisher.C; Cave.T; Wang.D | 2.4h |  |
| 37 | 6.19 | Module Move -TM1-SHC to TCS | 0.2d | 2016-04-01 13:00 | 2016-04-01 14:36 | 36 |  | 1.2d | 0d | start no earlier than 2016-03-04 08:00 | Wang.D; Cave.T | 3.2h |  |
| 38 | 6.20 | Module Connection- TM2 -TCS/Start of Pumps | 0.1d | 2016-04-01 14:36 | 2016-04-01 15:24 | 37 |  | 1.2d | 0d | start no earlier than 2016-03-04 08:00 | Wang.D | 0.8h |  |
| 39 | 6.21 | Module Disconnection-TM2-TCS | 0.25d | 2016-04-01 15:24 | 2016-04-04 08:24 | 38 |  | 1.2d | 0.95d | start no earlier than 2016-03-29 08:00 | Wang.D | 2h |  |
| 40 | 6.22 | Module Move-TM2- TCS to ITE | 0.25d | 2016-04-05 08:00 | 2016-04-05 10:00 | 39 |  | 0.25d | 0d | start no earlier than 2016-04-05 08:00 | Wang.D; Cave.T | 4h |  |
| 41 | 6.23 | Module Connection-TM2-ITW/ Start of Pumps | 0.5d | 2016-04-05 10:00 | 2016-04-05 15:00 | 40 |  | 0.25d |  | start no earlier than 2016-03-11 08:00 | McDonald.D; Wang.D | 8h |  |

| ID | WBS | Task | Duration | Start | Finish | Predecessors | Total slack | Free slack | Constraint | Resources | Work |
| --- | --- | --- | --- | --- | --- | --- | --- | --- | --- | --- | --- |
| 42 | 7 | **TM4 with New Lp Ta Target to ITE** | 5d? | 2016-04-06 08:00 | 2016-04-12 17:00 |  | 24d |  |  |  | 88h |
| 43 | 7.1 | New Lp Ta Target Insert into SHC | 0.1d | 2016-04-06 08:00 | 2016-04-06 08:48 | 41 | 24d | 0d | start no earlier than 2016-04-06 08:00 | Fisher.C; Mjos.A | 1.6h |
| 44 | 7.2 | Module Move -TM4-ITE to SHC | 0.3d | 2016-04-06 08:48 | 2016-04-06 11:12 | 43 | 24d | 0d | start no earlier than 2016-03-16 08:00 | Cave.T; Wang.D | 4.8h |
| 45 | 7.3 | Target Removal and Electrical Check | 0.2d | 2016-04-06 11:12 | 2016-04-06 13:48 | 44 | 24d | 0d | start no earlier than 2016-03-16 08:00 | Wang.D; Cave.T | 3.2h |
| 46 | 7.4 | New Target Installation | 0.2d | 2016-04-06 13:48 | 2016-04-06 15:24 | 45 | 24d | 0d | start no earlier than 2016-03-16 08:00 | Fisher.C | 1.6h |
| 47 | 7.5 | Leak Check and Electrical Check | 0.2d | 2016-04-06 15:24 | 2016-04-06 17:00 | 46 | 24d | 0d | start no earlier than 2016-03-16 08:00 | Fisher.C; Cave.T; Wang.D | 4.8h |
| 48 | 7.6 | Module Move -TM4-SHC to TCS | 0.5d | 2016-04-07 08:00 | 2016-04-07 12:00 | 47 | 24d | 0d | start no earlier than 2016-03-17 08:00 | Cave.T; Wang.D | 8h |
| 49 | 7.7 | Module Connection- TM4 -ITW/ Start of Pumps | 0.5d | 2016-04-07 13:00 | 2016-04-07 17:00 | 48 | 24d | 0d | start no earlier than 2016-03-09 08:00 | Wang.D; McDonald.D | 8h |
| 50 | 7.8 | Target Inspection | 0.5d | 2016-04-08 08:00 | 2016-04-08 12:00 | 49 | 24d | 0d | start no earlier than 2016-03-18 08:00 | Fisher.C; Mjos.A | 8h |
| 51 | 7.9 | Spent Target Move | 0.5d | 2016-04-08 13:00 | 2016-04-08 17:00 | 50 | 24d | 0d | start no earlier than 2016-03-21 08:00 | Cave.T; Fisher.C; Wang.D | 12h |
| 52 | 7.10 | Module Check-TM4 -TCS-Electrical, Vacuum | 1d? | 2016-04-11 08:00 | 2016-04-11 17:00 | 51 | 24d | 0d | start no earlier than 2016-04-11 08:00 | Cave.T; Wang.D | 16h |
| 53 | 7.11 | Module Move- TM4-TCS to ITE | 0.5d | 2016-04-12 08:00 | 2016-04-12 12:00 | 52 | 24d | 0d | start no earlier than 2016-04-12 08:00 | Cave.T; McDonald.D; Wang.D | 12h |
| 54 | 7.12 | Module Connection-TM4 -ITE/ Start of Pumps | 0.5d | 2016-04-12 13:00 | 2016-04-12 17:00 | 53 | 24d |  | start no earlier than 2016-04-12 08:00 | McDonald.D; Wang.D | 8h |
| 55 | 8 | **TM2 Check in TCS** | 9d | 2016-04-13 08:00 | 2016-04-25 17:00 |  | 0d |  |  |  | 88h |
| 56 | 8.1 | Module Move-TM2-Silo to TCS | 0.5d | 2016-04-13 08:00 | 2016-04-13 12:00 |  | 0d |  | start no earlier than 2016-04-13 08:00 | Cave.T; Wang.D | 8h |
| 57 | 8.2 | Module Connection-TM2-TCS/ Start of Pumps | 0.5d | 2016-04-13 13:00 | 2016-04-13 17:00 | 56 | 0d |  | start no earlier than 2016-04-13 08:00 | Wang.D | 4h |
| 58 | 8.3 | Module Pump Down-TM2 -TCS | 3d | 2016-04-14 08:00 | 2016-04-18 17:00 | 57 | 0d |  | finish no earlier than 2016-04-18 17:00 |  |  |
| 59 | 8.4 | Module Check-TM2 -TCS-Vacuum, Helium, Water | 4d | 2016-04-19 08:00 | 2016-04-22 17:00 | 58 | 0d |  | start no earlier than 2016-04-19 08:00 | Mjos.A; Wang.D | 64h |
| 60 | 8.5 | Module disconnection-TM2-TCS | 0.5d | 2016-04-25 08:00 | 2016-04-25 12:00 | 59 | 0d |  | start no earlier than 2016-04-25 08:00 | Wang.D | 4h |
| 61 | 8.6 | Module Move- TCS to Silo | 0.5d | 2016-04-25 13:00 | 2016-04-25 17:00 | 60 | 0d |  | start no earlier than 2016-04-25 08:00 | Cave.T; Wang.D | 8h |
| 62 | 9 | TM3 Refurbishment | 15d | 2016-04-26 08:00 | 2016-05-16 17:00 | 61 | 0d |  | start no earlier than 2016-04-26 08:00 | RPG; Target Group; Wang.D | 360h |
